# Exercise_01

Schedule from MS Project, 2014-10-01 to 2015-01-13, costs in р., A marks actual dates.

## Calendars

- Стандартный: Mon-Fri 09:00-13:00, 14:00-18:00; Sat-Sun off.

## Resources

| Resource | Group | Rate |
| --- | --- | --- |
| Соловьева | ред | 500 |
| Лебедева | ред | 400 |
| Воробьева | ред | 400 |
| Воронова | ред | 400 |
| Птицына | ред | 450 |
| Зябликова | ред | 500 |
| Гусева | ред | 600 |
| Корректор |  | 300 |
| Компьютер граф |  |  |
| Спасский |  | 400 |
| Шишкин |  | 300 |
| Бумага типогр |  | 10 |
| Типография |  |  |
| Транспорт |  |  |

## Schedule

| ID | WBS | Task | Duration | Start | Finish | Predecessors | Complete | Remaining | Baseline start | Baseline finish | Baseline duration | Total slack | Free slack | Resources | Work | Actual work | Cost | Baseline cost | Число страниц |
| --- | --- | --- | --- | --- | --- | --- | --- | --- | --- | --- | --- | --- | --- | --- | --- | --- | --- | --- | --- |
| 1 | 1 | Отбор статей | 2d | 2014-10-01 09:00 | 2014-10-02 18:00 |  |  |  | 2014-10-01 09:00 | 2014-10-02 18:00 | 2d | 8.25d | 0d | Воробьева; Воронова; Гусева; Зябликова | 64h |  | 30,400 |  |  |
| 2 | 2 | **Редактирование** | 15d | 2014-10-03 09:00 | 2014-10-23 18:00 | 1 |  |  | 2014-10-03 09:00 | 2014-10-10 18:00 | 6d | 0d |  |  | 288h |  | 122,000 | 122,000 |  |
| 3 | 2.1 | Ред_Статья 1 | 3d | 2014-10-16 09:00 | 2014-10-20 18:00 |  |  |  | 2014-10-03 09:00 | 2014-10-07 18:00 | 3d | 2.62d | 0d | Воробьева | 24h |  | 9,600 | 9,600 | 44 |
| 4 | 2.2 | Ред_Статья 2 | 2d | 2014-10-03 09:00 | 2014-10-06 18:00 |  |  |  | 2014-10-03 09:00 | 2014-10-06 18:00 | 2d | 12.88d | 0d | Птицына | 16h |  | 7,200 | 7,200 | 32 |
| 5 | 2.3 | Ред_Статья 3 | 6d | 2014-10-03 09:00 | 2014-10-10 18:00 |  |  |  | 2014-10-03 09:00 | 2014-10-10 18:00 | 6d | 8.25d | 0d | Лебедева | 48h |  | 19,200 | 19,200 | 67 |
| 6 | 2.4 | Ред_Статья 4 | 3d | 2014-10-03 09:00 | 2014-10-07 18:00 |  |  |  | 2014-10-03 09:00 | 2014-10-07 18:00 | 3d | 11.88d | 0d | Соловьева | 24h |  | 12,000 | 12,000 | 35 |
| 7 | 2.5 | Ред_Статья 5 | 3d | 2014-10-21 09:00 | 2014-10-23 18:00 |  |  |  | 2014-10-03 09:00 | 2014-10-07 18:00 | 3d | 0d |  | Воробьева; Птицына | 48h |  | 20,400 | 20,400 | 31 |
| 8 | 2.6 | Ред_Статья 6 | 4d | 2014-10-10 09:00 | 2014-10-15 18:00 |  |  |  | 2014-10-03 09:00 | 2014-10-08 18:00 | 4d | 5.62d | 0d | Воробьева | 32h |  | 12,800 | 12,800 | 47 |
| 9 | 2.7 | Ред_Статья 7 | 5d | 2014-10-03 09:00 | 2014-10-09 18:00 |  |  |  | 2014-10-03 09:00 | 2014-10-09 18:00 | 5d | 9d | 0d | Воробьева | 40h |  | 16,000 | 16,000 | 61 |
| 10 | 2.8 | Ред_Статья 8 | 2d | 2014-10-08 09:00 | 2014-10-09 18:00 |  |  |  | 2014-10-03 09:00 | 2014-10-06 18:00 | 2d | 9.88d | 0d | Соловьева | 16h |  | 8,000 | 8,000 | 19 |
| 11 | 2.9 | Ред_Статья 9 | 1d | 2014-10-10 09:00 | 2014-10-10 18:00 |  |  |  | 2014-10-03 09:00 | 2014-10-03 18:00 | 1d | 9d | 0d | Соловьева | 8h |  | 4,000 | 4,000 | 12 |
| 12 | 2.10 | Ред_Статья 10 | 4d | 2014-10-13 09:00 | 2014-10-16 18:00 |  |  |  | 2014-10-03 09:00 | 2014-10-08 18:00 | 4d | 4.75d | 0d | Лебедева | 32h |  | 12,800 | 12,800 | 54 |
| 13 | 3 | **Корректура** | 13.25d | 2014-10-07 09:00 | 2014-10-24 11:00 |  |  |  | 2014-10-06 09:00 | 2014-10-13 16:00 | 5.75d | 0d |  |  | 39h |  | 11,700 | 11,700 |  |
| 14 | 3.1 | Корр_Статья 1 | 5h | 2014-10-21 09:00 | 2014-10-21 15:00 | 3 |  |  | 2014-10-08 09:00 | 2014-10-08 15:00 | 5h | 2.62d |  | Корректор | 5h |  | 1,500 | 1,500 |  |
| 15 | 3.2 | Корр_Статья 2 | 3h | 2014-10-07 09:00 | 2014-10-07 12:00 | 4 |  |  | 2014-10-07 09:00 | 2014-10-07 12:00 | 3h | 12.88d |  | Корректор | 3h |  | 900 | 900 |  |
| 16 | 3.3 | Корр_Статья 3 | 6h | 2014-10-13 12:00 | 2014-10-14 10:00 | 5 |  |  | 2014-10-13 09:00 | 2014-10-13 16:00 | 6h | 8.12d |  | Корректор | 6h |  | 1,800 | 1,800 |  |
| 17 | 3.4 | Корр_Статья 4 | 3h | 2014-10-08 09:00 | 2014-10-08 12:00 | 6 |  |  | 2014-10-08 09:00 | 2014-10-08 12:00 | 3h | 11.88d |  | Корректор | 3h |  | 900 | 900 |  |
| 18 | 3.5 | Корр_Статья 5 | 2h | 2014-10-24 09:00 | 2014-10-24 11:00 | 7 |  |  | 2014-10-08 09:00 | 2014-10-08 11:00 | 2h | 0d |  | Корректор | 2h |  | 600 | 600 |  |
| 19 | 3.6 | Корр_Статья 6 | 5h | 2014-10-16 09:00 | 2014-10-16 15:00 | 8 |  |  | 2014-10-09 09:00 | 2014-10-09 15:00 | 5h | 5.62d |  | Корректор | 5h |  | 1,500 | 1,500 |  |
| 20 | 3.7 | Корр_Статья 7 | 6h | 2014-10-10 12:00 | 2014-10-13 12:00 | 9 |  |  | 2014-10-10 09:00 | 2014-10-10 16:00 | 6h | 8.88d |  | Корректор | 6h |  | 1,800 | 1,800 |  |
| 21 | 3.8 | Корр_Статья 8 | 3h | 2014-10-10 09:00 | 2014-10-10 12:00 | 10 |  |  | 2014-10-07 09:00 | 2014-10-07 12:00 | 3h | 9.88d |  | Корректор | 3h |  | 900 | 900 |  |
| 22 | 3.9 | Корр_Статья 9 | 2h | 2014-10-13 09:00 | 2014-10-13 11:00 | 11 |  |  | 2014-10-06 09:00 | 2014-10-06 11:00 | 2h | 9d |  | Корректор | 2h |  | 600 | 600 |  |
| 23 | 3.10 | Корр_Статья 10 | 4h | 2014-10-17 09:00 | 2014-10-17 13:00 | 12 |  |  | 2014-10-09 09:00 | 2014-10-09 13:00 | 4h | 4.75d |  | Корректор | 4h |  | 1,200 | 1,200 |  |
| 24 | 4 | Авторская коррект | 10d? | 2014-10-24 11:00 | 2014-11-07 11:00 | 13 |  |  | 2014-10-13 16:00 | 2014-10-27 16:00 | 10d? | 0d |  |  |  |  |  |  |  |
| 25 | 5 | Верстка | 8d | 2014-11-07 11:00 | 2014-11-19 11:00 | 24 |  |  | 2014-10-27 16:00 | 2014-11-06 16:00 | 8d | 0d |  | Компьютер граф; Спасский | 64h |  | 12,800 | 12,800 |  |
| 26 | 6 | Худ.оформл | 6d | 2014-11-19 11:00 | 2014-11-27 11:00 | 25 |  |  | 2014-11-06 16:00 | 2014-11-14 16:00 | 6d | 0d |  | Компьютер граф; Шишкин | 48h |  | 7,200 | 7,200 |  |
| 27 | 7 | Обложка | 11d | 2014-10-01 09:00 | 2014-10-15 18:00 |  |  |  | 2014-10-01 09:00 | 2014-10-15 18:00 | 11d | 30.25d | 0d | Компьютер граф; Шишкин | 100.8h |  | 15,840 | 15,840 |  |
| 28 | 8 | Печать | 3d | 2014-10-15 13:34 A | 2015-01-13 15:36 | 25, 26, 27 | 10% | 2.7d | 2014-10-15 13:34 | 2015-01-13 15:36 | 3d | 0d |  | Бумага типогр; Типография; Транспорт [0.1%] | 16.8h | 0.6h | 510 | 510 |  |
